# CRONOGRAMA ALCANTARILLADO SANITARIO

Schedule from MS Project, 2026-07-01 to 2026-09-29, status date 2022-09-01, costs in $, A marks actual dates.
Microsoft

## Calendars

- Estándar: Mon-Sun 08:00-12:00, 13:00-17:00.

## Resources

| Resource |
| --- |
| 126.70 |
| 298.78 |
| 3.48 |
| 523.62 |
| 275.74 |
| 1 |
| 956.04 |
| 431.75 |
| 745.81 |
| 159.54 |
| 8.61 |
| 124.40 |
| 502.50 |
| 939.00 |
| 2 |
| 492.98 |
| 538.80 |
| 172.30 |
| 99.72 |
| 58.72 |
| 278.95 |
| 3 |
| 106.13 |
| 508.34 |
| 51.24 |
| 670.28 |
| 69 |
| 620.00 |
| 65.00 |
| 362.56 |
| 585.98 |
| 107.60 |
| $126.70 |
| $298.78 |
| $3.48 |
| $523.62 |
| $275.74 |
| $1956.04 |
| $431.75 |
| $745.81 |
| $159.54 |
| $8.61 |
| $124.40 |
| $502.50 |
| $939.00 |
| $2492.98 |
| $538.80 |
| $172.30 |
| $99.72 |
| $58.72 |
| $278.95 |
| $3106.13 |
| $1508.34 |
| $51.24 |
| $670.28 |
| $69620.00 |
| $65.00 |
| $362.56 |
| $1585.98 |
| $107.60 |
| 15.21 |
| $70435.98 |
| $15.21 |
| $112.95 |
| $182.25 |
| $667.61 |
| $8.89 |
| $128.48 |
| $511.53 |
| $944.10 |
| $2544.51 |
| $55.60 |
| $555.60 |
| $176.04 |
| $103.02 |
| $58.80 |
| $293.54 |
| $670.88 |
| $365.68 |
| $254.95 |
| $254.94 |
| $163.29 |
| $66.18 |
| $295.99 |
| $671.89 |
| $2317.62 |
| $171.95 |
| $2330.29 |
| 132.09 |
| $ 132.09 |
| $ 68.54 |
| $132.09 |
| $ 298.88 |
| $ 559.36 |
| $ 165.44 |
| $ 2,057.81 |
| $ 259.55 |
| $ 2,495.90 |
| $ 175.26 |
| $ 2,362.48 |
| $ 525.88 |
| $ 949.80 |
| $ 2,606.19 |
| $ 567.00 |
| $ 182.72 |
| $ 103.80 |
| $ 62.24 |
| $ 293.15 |
| $ 3,134.82 |
| $ 1,521.27 |
| $ 52.99 |
| $ 673.12 |
| $ 70,435.98 |
| $ 15.30 |
| $ 65.00 |
| $ 366.76 |
| $ 1,585.98 |
| $ 107.60 |
| $ 298.71 |
| $ 696.57 |
| clnsc |

## Schedule

| ID | WBS | Task | Type | Duration | Start | Finish | Predecessors | Complete | Remaining | Cost | Actual cost | Cantidad | P.U. | Text4 | Text5 | Unidad |
| --- | --- | --- | --- | --- | --- | --- | --- | --- | --- | --- | --- | --- | --- | --- | --- | --- |
| 1 | 1 | **CONSTRUCCIÓN DE NUEVA RED DE DISTRIBUCIÓN DE AGUA POTABLE CON OTONGO PARA LAS ZONAS 3B-4B.** |  | 90d | 2026-07-01 A | 2026-09-29 |  | 1% | 88.8d | 792,872.47 | 1,229.93 |  |  |  |  |  |
| 2 | 1.1 | **Agua Potable** |  | 90d | 2026-07-01 A | 2026-09-29 |  | 1% | 88.8d | 792,872.47 | 1,229.93 |  |  |  |  |  |
| 3 | 1.1.1 | INICIO | milestone, manual | 0d | 2026-07-01 | 2026-07-01 |  |  |  |  |  |  |  |  |  |  |
| 4 | 1.1.2 | Replanteo y nivelación para redes hidrosanitarias. | manual | 80d | 2026-07-01 A | 2026-09-19 | 3 | 19% | 65d | 3,093.9 | 587.84 | 5524.82 | 0.56 | 132.09 | 132.09 |  |
| 5 | 1.1.3 | Rasanteo y preparación zanja (inc. Cama de arena). | manual | 80d | 2026-07-01 | 2026-09-19 | 4 |  |  | 17,170.75 |  | 4836.83 | 3.55 |  |  | M2 |
| 6 | 1.1.4 | Excavación de suelo natural <2 m (a máquina). | manual | 80d | 2026-07-01 | 2026-09-19 | 8 |  |  | 22,161.72 |  | 8300.27 | 2.67 |  |  | M3 |
| 7 | 1.1.5 | Excavación de suelo natural 2 a 4 m (a máquina). | manual | 60d | 2026-07-08 | 2026-09-06 |  |  |  | 326.77 |  | 101.48 | 3.22 |  |  | M3 |
| 8 | 1.1.6 | Excavación Suelo afirmado <2m (a máquina). | manual | 80d | 2026-07-01 A | 2026-09-19 |  | 13% | 70d | 4,939.17 | 642.09 | 923.21 | 5.35 | 165.44 | 165.44 | M3 |
| 9 | 1.1.7 | Desalojo a máquina (dist= 5 km). | manual | 75d | 2026-07-03 | 2026-09-16 | 8 |  |  | 12,528.87 |  | 1810.53 | 6.92 |  |  | M3 |
| 10 | 1.1.8 | Rotura y reposición pavimento asfaltico. | manual | 90d | 2026-07-01 | 2026-09-29 |  |  |  | 70,608.21 |  | 3180.55 | 22.20 |  |  | M2 |
| 11 | 1.1.9 | Relleno compactado con material de excavación. | manual | 60d | 2026-07-25 | 2026-09-23 |  |  |  | 29,009.42 |  | 8507.16 | 3.41 |  |  | M3 |
| 12 | 1.1.10 | Sum/Ins/Tra Codo PVC d=315 mm x 22.5° UE. | manual | 30d | 2026-08-18 | 2026-09-17 |  |  |  | 4,351.92 |  | 12.00 | 362.66 | 949.8 | 949.8 |  |
| 13 | 1.1.11 | Sum/Ins/Tra Codo PVC d=315mm x 45° UE. | manual | 30d | 2026-08-18 | 2026-09-17 |  |  |  | 730.74 |  | 2.00 | 365.37 | 2606.19 | 2606.19 |  |
| 14 | 1.1.12 | Sum/Ins/Tra Codo PVC d=315mm x 90° UE. | manual | 30d | 2026-08-18 | 2026-09-17 |  |  |  | 834.82 |  | 2.00 | 417.41 | 567 | 567 |  |
| 15 | 1.1.13 | Sum/Ins/Tra Codo PVC d=400 mm x 11.25° UE. | manual | 40d | 2026-07-12 | 2026-08-21 |  |  |  | 24,035.84 |  | 41.00 | 586.24 | 182.72 | 182.72 |  |
| 16 | 1.1.14 | Sum/Ins/Tra Codo PVC d=400 mm x 22.5° UE. | manual | 40d | 2026-07-12 | 2026-08-21 |  |  |  | 2,354.56 |  | 4.00 | 588.64 | 103.8 | 103.8 |  |
| 17 | 1.1.15 | Sum/Ins/Tra Codo PVC d=400mm x 90° UE. | manual | 40d | 2026-07-12 | 2026-08-21 |  |  |  | 688.82 |  | 1.00 | 688.82 | 62.24 | 62.24 |  |
| 18 | 1.1.16 | Sum/Ins/Tra Cruz PVC d=315mm UE. | manual | 10d | 2026-08-18 | 2026-08-28 |  |  |  | 953.91 |  | 1.00 | 953.91 | 1521.27 | 1521.27 |  |
| 19 | 1.1.17 | Sum/Ins/Tra Reductor PVC d=315x160mm UE. | manual | 20d | 2026-08-12 | 2026-09-01 |  |  |  | 181.42 |  | 1.00 | 181.42 | 52.99 | 52.99 |  |
| 20 | 1.1.18 | Sum/Ins/Tra Reductor PVC d=315x200mm UE. | manual | 20d | 2026-08-12 | 2026-09-01 |  |  |  | 423.6 |  | 2.00 | 211.80 | 673.12 | 673.12 |  |
| 21 | 1.1.19 | Sum/Ins/Tra Reductor PVC d=400x160mm UE. | manual | 20d | 2026-07-12 | 2026-08-01 |  |  |  | 1,363.76 |  | 2.00 | 681.88 |  |  |  |
| 22 | 1.1.20 | Sum/Ins/Tra Tapón PVC d=160mm UE. | manual | 10d | 2026-07-22 | 2026-08-01 |  |  |  | 74.04 |  | 2.00 | 37.02 |  |  |  |
| 23 | 1.1.21 | Sum/Ins/Tra Tee o Yee d=315 mm UE. | manual | 25d | 2026-08-12 | 2026-09-06 |  |  |  | 500.13 |  | 1.00 | 500.13 |  |  |  |
| 24 | 1.1.22 | Sum/Ins/Tra Tee PVC d=200mm UE. | manual | 30d | 2026-07-30 | 2026-08-29 |  |  |  | 133.19 |  | 1.00 | 133.19 |  |  |  |
| 25 | 1.1.23 | Sum/Ins/Tra Tee PVC d=400mm UE. | manual | 40d | 2026-07-12 | 2026-08-21 |  |  |  | 4,413.36 |  | 7.00 | 630.48 |  |  |  |
| 26 | 1.1.24 | Sum/Ins/Tra Tubería PVC d=200mm 0.80MPa UE + Prueba. | manual | 20d | 2026-07-30 | 2026-08-19 | 12, 16, 18, 22, 23 |  |  | 456.75 |  | 15.00 | 30.45 |  |  |  |
| 27 | 1.1.25 | Sum/Ins/Tra Tubería PVC d=315mm 0.80MPa UE + Prueba. | manual | 50d | 2026-08-03 | 2026-09-22 | 24, 13 |  |  | 86,107.67 |  | 1301.90 | 66.14 |  |  |  |
| 28 | 1.1.26 | Sum/Ins/Tra Tubería PVC d=400mm 0.80MPa UE + Prueba. | manual | 60d | 2026-07-01 | 2026-08-30 | 32 |  |  | 251,020.28 |  | 2542.75 | 98.72 |  |  |  |
| 29 | 1.1.27 | Sum/Ins/Tra Reductor PVC d=400x200mm UE. | manual | 20d | 2026-07-22 | 2026-08-11 | 15, 25, 21, 20, 17, 31 |  |  | 2,525.48 |  | 4.00 | 631.37 |  |  |  |
| 30 | 1.1.28 | Sum/Ins/Tra Reductor PVC d=400x315mm UE. | manual | 20d | 2026-07-12 | 2026-08-01 | 29 |  |  | 1,958.36 |  | 2.00 | 979.18 |  |  |  |
| 31 | 1.1.29 | Ins/Tra Tubería PVC d=400mm 0.80MPa UE + Prueba. | manual | 60d | 2026-07-01 | 2026-08-30 | 27, 32, 19, 14 |  |  | 29,343.39 |  | 1695.17 | 17.31 |  |  |  |
| 32 | 1.1.30 | Suministro Tubería PVC d=400mm 0.80MPa UE. | manual | 60d | 2026-07-01 | 2026-08-30 |  |  |  | 138,003.79 |  | 1695.17 | 81.41 |  |  |  |
| 33 | 1.1.31 | Sum/Ins/Tra Tapa Redonda HD 600mm. | manual | 10d | 2026-09-19 | 2026-09-29 |  |  |  | 4,100.64 |  | 12.00 | 341.72 |  |  |  |
| 34 | 1.1.32 | Sum/Ins/Tra Caja Válvula Tipo IEOS d=150mm. | manual | 15d | 2026-07-22 | 2026-08-06 |  |  |  | 124.78 |  | 2.00 | 62.39 |  |  |  |
| 35 | 1.1.33 | Sum/Ins/tra Válvula de Compuerta HD E/L d=160 mm. | manual | 10d | 2026-08-06 | 2026-08-16 | 34 |  |  | 1,317.08 |  | 2.00 | 658.54 |  |  |  |
| 36 | 1.1.34 | Sum/Ins/Tra Válvula de Compuerta HD E/L d=200mm. | manual | 20d | 2026-07-22 | 2026-08-11 | 29 |  |  | 1,861.62 |  | 2.00 | 930.81 |  |  |  |
| 37 | 1.1.35 | Sum/Ins/Tra Válvula de Compuerta HD E/L d=315mm. | manual | 30d | 2026-08-08 | 2026-09-07 |  |  |  | 3,804.58 |  | 2.00 | 1902.29 |  |  |  |
| 38 | 1.1.36 | Sum/Ins/Tra Valvula de Compuerta HD E/L d=400mm. | manual | 30d | 2026-07-12 | 2026-08-11 |  |  |  | 4,146.89 |  | 1.00 | 4146.89 |  |  |  |
| 39 | 1.1.37 | Sum/Ins/Tra Válvula de Desagüe HD d=200mm con accesorios. | manual | 30d | 2026-07-22 | 2026-08-21 |  |  |  | 2,398.12 |  | 2.00 | 1199.06 |  |  |  |
| 40 | 1.1.38 | Sum/Ins/Tra Unión Gibault HF Asimétrica d=160mm. | manual | 10d | 2026-07-24 | 2026-08-03 | 36 |  |  | 227.16 |  | 4.00 | 56.79 |  |  |  |
| 41 | 1.1.39 | Sum/Ins/Tra Unión GIbault HF Asimétrica d=200mm. | manual | 20d | 2026-07-22 | 2026-08-11 | 39 |  |  | 324.92 |  | 4.00 | 81.23 |  |  |  |
| 42 | 1.1.40 | Sum/Ins/Tra Unión Gibault HF Asimétrica d=315mm. | manual | 30d | 2026-08-08 | 2026-09-07 | 37 |  |  | 618.6 |  | 4.00 | 154.65 |  |  |  |
| 43 | 1.1.41 | Sum/Ins/Tra Union Gibault HF Asimetrica d=400mm. | manual | 30d | 2026-07-12 | 2026-08-11 | 45 |  |  | 442.44 |  | 2.00 | 221.22 |  |  |  |
| 44 | 1.1.42 | Hormigón Simple en replantillos f`c=140 kg/cm2. | manual | 65d | 2026-07-08 | 2026-09-11 |  |  |  | 1,127.07 |  | 6.64 | 169.74 |  |  | M3 |
| 45 | 1.1.43 | Hormigón simple f`c=210 kg/cm2 con encofrado. | manual | 60d | 2026-07-12 | 2026-09-10 |  |  |  | 13,515.53 |  | 54.36 | 248.63 |  |  | M3 |
| 46 | 1.1.44 | Sum/Ins/Tra Tubería PVC d=160mm 0.80MPa UE. | manual | 20d | 2026-07-20 | 2026-08-09 |  |  |  | 415.68 |  | 24.00 | 17.32 |  |  |  |
| 47 | 1.1.45 | Sum/Ins/Tra Tubería PVC d=200mm 0.80MPa UE. | manual | 20d | 2026-07-20 | 2026-08-09 | 26, 48, 50 |  |  | 880.32 |  | 32.00 | 27.51 |  |  |  |
| 48 | 1.1.46 | Sum/Ins/Tra Collarín HD d=315mm con salida bridada 3". | manual | 10d | 2026-07-20 | 2026-07-30 |  |  |  | 804.26 |  | 2.00 | 402.13 |  |  |  |
| 49 | 1.1.47 | Sum/Ins/Tra Collarín HD d=400mm con salida bridada 3". | manual | 10d | 2026-07-20 | 2026-07-30 | 48, 47 |  |  | 1,747 |  | 4.00 | 436.75 |  |  |  |
| 50 | 1.1.48 | Sum/Ins/Tra Acero de Refuerzo fy=4200 kg/cm2. | manual | 60d | 2026-07-08 | 2026-09-06 | 31 |  |  | 11,424.98 |  | 4360.68 | 2.62 |  |  | Kg |
| 51 | 1.1.49 | Sum/Ins/Tra Válvula de mariposa BB 75mm. | manual | 10d | 2026-07-20 | 2026-07-30 | 23 |  |  | 2,246.7 |  | 6.00 | 374.45 |  |  |  |
| 52 | 1.1.50 | Sum/Ins/Tra Válvula de aire Tripleaccion D-065 3" Bridada. | manual | 30d | 2026-07-20 | 2026-08-19 | 51 |  |  | 13,605 |  | 6.00 | 2267.50 |  |  |  |
| 53 | 1.1.51 | Hormigón simple f`c=180 kg/cm2 con encofrado. | manual | 80d | 2026-07-11 | 2026-09-29 |  |  |  | 17,444.46 |  | 73.17 | 238.41 |  |  | M3 |
| 54 | 1.1.52 | FIN | milestone, manual | 0d | 2026-09-29 | 2026-09-29 | 33 |  |  |  |  |  |  |  |  |  |

Notes:
- 19: Se tomaran 15 dias antes para tramites de instalación en la empresa CNEL.
